# Video-gen

Schedule from MS Project, 2007-01-16 to 2007-04-28.
Home

## Calendars

- Standard: Mon-Sat 08:00-12:00, 13:00-17:00; Sun off.

## Resources

| Resource |
| --- |
| Hrishkesh |
| Aparna |

## Schedule

| ID | WBS | Task | Duration | Start | Finish | Predecessors | Total slack | Free slack | Constraint | Resources | Work |
| --- | --- | --- | --- | --- | --- | --- | --- | --- | --- | --- | --- |
| 1 | 1 | **Video Generator** | 89d? | 2007-01-16 | 2007-04-28 |  | 0d |  |  | Hrishkesh [50%]; Aparna [50%] | 2200h |
| 2 | 1.1 | **Phase I - Study** | 21d? | 2007-01-16 | 2007-02-08 |  | 0d |  |  |  | 288h |
| 3 | 1.1.1 | **FPGA** | 8d? | 2007-01-16 | 2007-01-24 |  | 0d |  |  |  | 112h |
| 4 | 1.1.1.1 | What are FPGA's | 2d | 2007-01-16 | 2007-01-17 |  | 0d |  |  | Hrishkesh; Aparna | 32h |
| 5 | 1.1.1.2 | How are FPGA's programmed | 3d | 2007-01-18 | 2007-01-20 | 4 | 0d |  |  | Hrishkesh; Aparna | 48h |
| 6 | 1.1.1.3 | XESS/Digilent FPGA Boards | 2d | 2007-01-22 | 2007-01-23 | 5 | 0d |  |  | Hrishkesh; Aparna | 32h |
| 7 | 1.1.1.4 | Documentation | 1d? | 2007-01-24 | 2007-01-24 | 6 | 0d |  |  |  |  |
| 8 | 1.1.2 | **Video Signals** | 7d? | 2007-01-25 | 2007-02-01 |  | 0d |  |  |  | 96h |
| 9 | 1.1.2.1 | What is video? | 1d | 2007-01-25 | 2007-01-25 | 3 | 0d |  | start no earlier than 2007-01-25 | Hrishkesh; Aparna | 16h |
| 10 | 1.1.2.2 | Raster Scanning | 1d? | 2007-01-26 | 2007-01-26 | 9 | 0d |  |  | Hrishkesh; Aparna | 16h |
| 11 | 1.1.2.3 | Concepts of RGB Signals | 2d? | 2007-01-27 | 2007-01-29 | 10 | 0d |  |  | Hrishkesh; Aparna | 32h |
| 12 | 1.1.2.4 | Importance of HS and VS | 2d | 2007-01-30 | 2007-01-31 | 11 | 0d |  |  | Hrishkesh; Aparna | 32h |
| 13 | 1.1.2.5 | Documentation | 1d? | 2007-02-01 | 2007-02-01 | 12 | 0d |  |  |  |  |
| 14 | 1.1.3 | **Xilinx ISE Webpack** | 6d? | 2007-02-02 | 2007-02-08 |  | 0d |  |  |  | 80h |
| 15 | 1.1.3.1 | Get familiar with Xilinx Tools | 1d? | 2007-02-02 | 2007-02-02 | 8 | 0d |  | start no earlier than 2007-02-02 | Hrishkesh; Aparna | 16h |
| 16 | 1.1.3.2 | Understand the concepts of Synthesis | 1d? | 2007-02-03 | 2007-02-03 | 15 | 0d |  |  | Hrishkesh; Aparna | 16h |
| 17 | 1.1.3.3 | Understand the concept of mapping | 1d | 2007-02-05 | 2007-02-05 | 16 | 0d |  |  | Hrishkesh; Aparna | 16h |
| 18 | 1.1.3.4 | Dummy code download on the board | 2d | 2007-02-06 | 2007-02-07 | 17 | 0d |  | start no earlier than 2007-01-31 | Hrishkesh; Aparna | 32h |
| 19 | 1.1.3.5 | Documentation | 1d? | 2007-02-08 | 2007-02-08 | 18 | 0d |  |  |  |  |
| 20 | 1.2 | **Phase II - Generate RGB** | 10d? | 2007-02-09 | 2007-02-20 |  | 0d |  |  |  | 128h |
| 21 | 1.2.1 | Verilog Code to generate HS and VS | 5d | 2007-02-09 | 2007-02-14 | 2 | 2d | 0d | start no earlier than 2007-02-09 | Aparna | 40h |
| 22 | 1.2.2 | Testbench to test HS and VS | 3d | 2007-02-15 | 2007-02-17 | 21 | 2d |  |  | Aparna | 24h |
| 23 | 1.2.3 | Verilog Code to generate RGB | 5d | 2007-02-09 | 2007-02-14 | 2 | 0d |  | start no earlier than 2007-02-09 | Hrishkesh | 40h |
| 24 | 1.2.4 | Testbench to test RGB generation | 3d | 2007-02-15 | 2007-02-17 | 23 | 0d |  |  | Hrishkesh | 24h |
| 25 | 1.2.5 | Phase II Documentation | 2d? | 2007-02-19 | 2007-02-20 | 24 | 0d |  |  |  |  |

| ID | WBS | Task | Duration | Start | Finish | Predecessors | Total slack | Free slack | Constraint | Resources | Work |
| --- | --- | --- | --- | --- | --- | --- | --- | --- | --- | --- | --- |
| 26 | 1.3 | **Phase III - Generate patterns** | 17d? | 2007-02-21 | 2007-03-12 |  | 0d |  |  |  | 240h |
| 27 | 1.3.1 | Verilog code to generate a circle | 5d | 2007-02-21 | 2007-02-26 | 20 | 2d | 0d |  | Hrishkesh | 40h |
| 28 | 1.3.2 | Testbench to test the above | 3d | 2007-02-27 | 2007-03-01 | 27 | 2d | 0d |  | Hrishkesh | 24h |
| 29 | 1.3.3 | Verilog code to generate Squar | 5d | 2007-02-21 | 2007-02-26 | 20 | 0d |  |  | Aparna | 40h |
| 30 | 1.3.4 | Testbench | 3d | 2007-02-27 | 2007-03-01 | 29 | 0d |  |  | Aparna | 24h |
| 31 | 1.3.5 | Generate pattern given the coordinates | 7d | 2007-03-02 | 2007-03-09 | 28 | 2d |  |  | Hrishkesh | 56h |
| 32 | 1.3.6 | Testbench | 7d | 2007-03-02 | 2007-03-09 | 30 | 0d |  |  | Aparna | 56h |
| 33 | 1.3.7 | Phase III Documentation | 2d? | 2007-03-10 | 2007-03-12 | 32 | 0d |  |  |  |  |
| 34 | 1.4 | **Phase IV** | 27d? | 2007-03-13 | 2007-04-12 |  | 0d |  |  | Hrishkesh; Aparna | 832h |
| 35 | 1.4.1 | Human Interface<TBD> | 25d? | 2007-03-13 | 2007-04-10 | 26 | 0d |  | start no earlier than 2007-03-09 | Hrishkesh; Aparna | 400h |
| 36 | 1.4.2 | Phase IV Documentation | 2d? | 2007-04-11 | 2007-04-12 | 35 | 0d |  |  |  |  |
| 37 | 1.5 | **Documentation** | 14d? | 2007-04-13 | 2007-04-28 |  | 0d |  |  |  |  |
| 38 | 1.5.1 | Final report | 14d? | 2007-04-13 | 2007-04-28 | 34 | 0d |  | start no earlier than 2007-04-13 |  |  |
